# DPIC-PO-NEC-299-1002

Schedule from Primavera P6, 2021-08-11 to 2022-10-04, data date 2021-12-16, costs in USD, A marks actual dates.

## Calendars

- Standard: Mon-Sun 08:00-12:00, 13:00-17:00.

## Resources

| Resource | Group | Rate |
| --- | --- | --- |
| (New Resource) | labor | 1 |

## Schedule

| ID | WBS | Activity | Type | Duration | Start | Finish | Predecessors | Complete | Remaining | Planned start | Planned finish | Total float | Free float | Resources | Cost | % Plan for Report | % Actual for Report | Gate Status | % WF | QA/QC |
| --- | --- | --- | --- | --- | --- | --- | --- | --- | --- | --- | --- | --- | --- | --- | --- | --- | --- | --- | --- | --- |
|  | 1 | **DPIC-PO-NEC-299-1002** |  |  | 2021-08-11 | 2022-10-04 |  |  |  |  |  |  |  |  |  |  |  |  |  |  |
| 222 |  | Finish | milestone | 0d | 2022-10-04 | 2022-10-04 | 221 |  |  |  |  | 0d |  |  |  | 0 | 0 |  |  |  |
|  | 1 | **Milestones** |  |  | 2021-08-11 | 2021-09-14 |  |  |  |  |  |  |  |  |  |  |  |  |  |  |
| 3 |  | LOI Date | milestone | 0d | 2021-08-11 | 2021-08-11 |  |  |  |  |  | 0d |  |  |  | 0 | 0 |  |  |  |
| 4 |  | Effective Date | milestone | 0d | 2021-08-11 | 2021-08-11 | 3 |  |  |  |  | 0d |  |  |  | 0 | 0 |  |  |  |
| 6 |  | Bank Garanty Payment Date | milestone | 0d | 2021-08-11 | 2021-08-11 | 4 |  |  |  |  | 0d |  |  |  | 0 | 0 |  |  |  |
| 7 |  | Advanced Payment Date | milestone | 0d | 2021-08-11 | 2021-08-11 | 3, 6 |  |  |  |  | 0d |  |  |  | 0 | 0 |  |  |  |
| 5 |  | K.O.M | milestone | 0d | 2021-09-14 | 2021-09-14 | 4 FS+34d |  |  |  |  | 137.75d | 0d |  |  | 0 | 0 |  |  |  |
|  | 2 | **Engineering** |  |  | 2021-08-15 | 2022-03-20 |  |  |  |  |  |  |  |  |  |  |  |  |  |  |
|  | 1 | **GENERAL DOCUMENT** |  |  | 2021-08-15 | 2021-10-12 |  |  |  |  |  |  |  |  |  |  |  |  |  |  |
| 10 |  | Vendor Print Index & Schedule (VPIS) | resource dependent | 20.88d | 2021-08-15 A | 2021-09-04 | 7 FS+4d | 80% | 20.88d |  |  | 0d |  | (New Resource) | 0.2 | 0.2 | 0.16 | UDF_G2 | 0.2 |  |
| 14 |  | Sub Vendor List | resource dependent | 21d | 2021-09-19 A | 2021-10-10 | 10 FS+15d | 80% | 21d |  |  | 334d | 140.12d | (New Resource) | 0.1 | 0.1 | 0.06 | UDF_G2 | 0.1 |  |
| 11 |  | WBS | resource dependent | 21d | 2021-09-21 | 2021-10-11 | 5 FS+7d |  |  |  |  | 137.75d | 0d | (New Resource) | 0.1 | 0.1 | 0.1 | UDF_G3 | 0.1 |  |
| 12 |  | Time Schedule | resource dependent | 39.88d | 2021-10-12 A | 2021-10-12 | 11 | 100% | 0d | 2021-10-12 | 2021-11-20 | 332.88d | 0d | (New Resource) | 0.05 | 0.05 | 0.03 | UDF_G2 | 0.05 |  |
| 13 |  | Project Monthly Report for Refrigeration Packages | resource dependent | 30d | 2021-11-02 A | 2021-10-12 | 12 | 60% | 0d | 2021-11-02 | 2021-12-01 | 332.88d | 139d | (New Resource) | 0.05 | 0.0433333333333333 | 0.03 | UDF_G3 | 0.05 |  |
|  | 2 | **ENGINEERING DOCUMENT** |  |  | 2021-08-29 | 2022-03-20 |  |  |  |  |  |  |  |  |  |  |  |  |  |  |
| 29 |  | Compressor Drawing | resource dependent | 90d | 2021-08-29 | 2021-11-26 | 34 SS-49d |  |  |  |  | 5.75d | 0d | (New Resource) | 0.05 | 0.05 | 0.03 | UDF_G2 | 0.05 | UDF_G4 |
| 34 |  | Process Flow Diagram (PFD) | resource dependent | 60d | 2021-10-17 | 2021-12-15 | 10 FS+42d |  |  |  |  | 0d |  | (New Resource) | 0.1 | 0.07 | 0.08 | UDF_G2 | 0.1 | UDF_G4 |
| 39 |  | Condensor Data Sheet | resource dependent | 20.88d | 2021-10-31 | 2021-11-20 | 34 FS-46d, 10 |  |  |  |  | 18.25d | 0d | (New Resource) | 0.04 | 0.04 | 0.024 | UDF_G2 | 0.04 | UDF_G4 |
| 42 |  | Economizer Data Sheet | resource dependent | 20.88d | 2021-10-31 | 2021-11-20 | 34 FS-46d |  |  |  |  | 17.25d | 0d | (New Resource) | 0.04 | 0.04 | 0.024 | UDF_G2 | 0.04 | UDF_G4 |
| 71 |  | Thermal Calculation for Heat Exchangers | resource dependent | 50d | 2021-10-31 | 2021-12-19 | 34 FS-46d |  |  |  |  | 158.75d |  | (New Resource) | 0.3 | 0.168 | 0.18 | UDF_G2 | 0.3 | UDF_G4 |
| 36 |  | Oil Cooler Data Sheet | resource dependent | 21d | 2021-11-01 | 2021-11-21 | 10, 34 FS-45d |  |  |  |  | 17.12d | 0d | (New Resource) | 0.04 | 0.04 | 0.024 | UDF_G2 | 0.04 | UDF_G4 |
| 84 |  | Evaporator Data Sheet | resource dependent | 30d | 2021-11-07 | 2021-12-06 | 34 FS-39d |  |  |  |  | 21.12d | 0d | (New Resource) | 0.04 | 0.028 | 0.024 | UDF_G2 | 0.04 | UDF_G4 |
| 17 |  | Piping and Instrument Diagram (PID) | resource dependent | 29.88d | 2021-11-11 A | 2021-12-11 | 10 FS+68d | 60% | 29.88d |  |  | 0d |  | (New Resource) | 0.1 | 0.0539748953974895 | 0.06 | UDF_G2 | 0.1 | UDF_G4 |
| 41 |  | K/O Drum Data Sheet | resource dependent | 20.88d | 2021-11-21 | 2021-12-11 | 34 FS-25d |  |  |  |  | 6.12d | 0.12d | (New Resource) | 0.04 | 0.0134131736526946 | 0.024 | UDF_G2 | 0.04 | UDF_G4 |
| 35 |  | Main Motor Drawing | resource dependent | 20.88d | 2021-11-23 | 2021-12-13 | 34 FS-23d, 10 FS+16d |  |  |  |  | 25.12d | 19.12d | (New Resource) | 0.05 | 0.0119760479041916 | 0 |  | 0.05 |  |
| 18 |  | General Arrangement Drawing Including Loads, Displacement, and Maintenace Info | resource dependent | 30d | 2021-11-23 A | 2021-12-23 | 17 FS-18d | 60% | 30d |  |  | 0d |  | (New Resource) | 0.3 | 0.0425 | 0 |  | 0.3 | UDF_G4 |
| 52 |  | Instrument Cable List | resource dependent | 20.88d | 2021-11-25 | 2021-12-15 | 34 FS-21d, 10 FS+60d |  |  |  |  | 58.88d |  | (New Resource) | 0.05 | 0.00718562874251497 | 0 |  | 0.05 |  |
| 61 |  | Instrument Calculations (Safety Relief Valves, Control Valves, Flow Meters, Restriction Orifices, …) | resource dependent | 21d | 2021-11-25 | 2021-12-15 | 34 FS-21d |  |  |  |  | 86.75d | 0d | (New Resource) | 0.04 | 0.00571428571428572 | 0 |  | 0.04 |  |
| 20 |  | Utility Consumption List | resource dependent | 21d | 2021-11-27 | 2021-12-17 | 34 FS-19d |  |  |  |  | 265.88d | 72d | (New Resource) | 0.04 | 0.0019047619047619 | 0 |  | 0.04 |  |
| 40 |  | Liquid Receiver Data Sheet | resource dependent | 21d | 2021-11-27 | 2021-12-17 | 34 FS-19d |  |  |  |  | 11.12d | 0d | (New Resource) | 0.04 | 0.0019047619047619 | 0.024 | UDF_G2 | 0.04 | UDF_G4 |
| 57 |  | Compressor Data Sheet | resource dependent | 21d | 2021-11-27 | 2021-12-17 | 29 |  |  |  |  | 5.75d | 0d | (New Resource) | 0.04 | 0.0019047619047619 | 0 | UDF_G1 | 0.04 |  |
| 59 |  | Process Description | resource dependent | 21d | 2021-11-27 | 2021-12-17 | 34 FS-19d |  |  |  |  | 251.88d | 5.75d | (New Resource) | 0.04 | 0.0019047619047619 | 0 |  | 0.04 |  |
| 85 |  | Evaporator Drawing | resource dependent | 20.88d | 2021-11-27 | 2021-12-17 | 84 FS-10d |  |  |  |  | 21.12d | 15.12d | (New Resource) | 0.05 | 0.00239520958083832 | 0 | UDF_G1 | 0.05 |  |
| 32 |  | Main Motor Data Sheet and Curve | resource dependent | 20.88d | 2021-11-28 | 2021-12-18 | 34 FS-18d |  |  |  |  | 0d | 0.12d | (New Resource) | 0.04 | 0 | 0 |  | 0.04 |  |
| 37 |  | Oil Pump Data Sheet | resource dependent | 21d | 2021-11-30 | 2021-12-20 | 34 FS-16d, 10 FS+23d |  |  |  |  | 18.12d | 0d | (New Resource) | 0.04 | 0 | 0 |  | 0.04 |  |
| 38 |  | Oil Separator Data Sheet | resource dependent | 21d | 2021-11-30 | 2021-12-20 | 34 FS-16d, 10 FS+23d |  |  |  |  | 18.12d | 0d | (New Resource) | 0.04 | 0 | 0 |  | 0.04 |  |
| 45 |  | Oil Pump Drawing | resource dependent | 20.88d | 2021-11-30 | 2021-12-20 | 37 SS |  |  |  |  | 18.12d | 6d | (New Resource) | 0.05 | 0 | 0 |  | 0.05 |  |
| 46 |  | Oil Separator Drawing | resource dependent | 20.88d | 2021-11-30 | 2021-12-20 | 38 SS |  |  |  |  | 18.12d | 6d | (New Resource) | 0.05 | 0 | 0 |  | 0.05 |  |
| 47 |  | Condensor Drawing | resource dependent | 20.88d | 2021-11-30 | 2021-12-20 | 39 SS+30d |  |  |  |  | 18.12d | 12.12d | (New Resource) | 0.05 | 0 | 0 |  | 0.05 |  |
| 82 |  | Material Safety Data Sheet | resource dependent | 21d | 2021-11-30 | 2021-12-20 | 34 FS-16d |  |  |  |  | 241.88d | 29d | (New Resource) | 0.04 | 0 | 0 |  | 0.04 |  |
| 50 |  | Economizer Drawing | resource dependent | 20.88d | 2021-11-30 | 2021-12-21 | 42 FS+10d |  |  |  |  | 17.25d | 11.25d | (New Resource) | 0.05 | 0 | 0 |  | 0.05 |  |
| 44 |  | Oil Cooler Drawing | resource dependent | 20.88d | 2021-12-01 | 2021-12-21 | 36 SS+30d |  |  |  |  | 17.12d | 5d | (New Resource) | 0.05 | 0 | 0 |  | 0.05 |  |
| 64 |  | Filter Dryer Data Sheet | resource dependent | 21d | 2021-12-01 A | 2021-12-21 | 34 FS-15d | 80% | 21d |  |  | 17.12d | 0d | (New Resource) | 0.04 | 0 | 0 |  | 0.04 | UDF_G4 |
| 65 |  | Filter Dryer Drawing | resource dependent | 20.88d | 2021-12-01 | 2021-12-21 | 64 SS |  |  |  |  | 17.12d | 11d | (New Resource) | 0.05 | 0 | 0 |  | 0.05 |  |
| 30 |  | Oil Filter Data Sheet | resource dependent | 21d | 2021-12-06 A | 2021-12-26 | 34 FS-10d | 80% | 21d |  |  | 5.88d | 0d | (New Resource) | 0.04 | 0 | 0.024 | UDF_G1 | 0.04 | UDF_G4 |
| 43 |  | Oil Pump Motor Data Sheet | resource dependent | 21d | 2021-12-06 | 2021-12-26 | 34 FS-10d |  |  |  |  | 12.12d | 0d | (New Resource) | 0.04 | 0 | 0 | UDF_G1 | 0.04 |  |
| 51 |  | Oil Pump Motor Drawing | resource dependent | 20.88d | 2021-12-06 | 2021-12-26 | 43 SS |  |  |  |  | 12.12d | 0d | (New Resource) | 0.05 | 0 | 0 | UDF_G1 | 0.05 |  |
| 48 |  | Liquid Receiver Drawing | resource dependent | 20.88d | 2021-12-07 | 2021-12-27 | 40 SS+10d |  |  |  |  | 11.12d | 5.12d | (New Resource) | 0.05 | 0 | 0 |  | 0.05 |  |
| 21 |  | Instrument Index List (Including Alarm & Trip Points) | resource dependent | 21d | 2021-12-11 | 2022-01-01 | 17 |  |  |  |  | 55d | 0d | (New Resource) | 0.04 | 0 | 0 |  | 0.04 |  |
| 23 |  | Control Narrative (Sequence Description) | resource dependent | 21d | 2021-12-11 | 2022-01-01 | 17 |  |  |  |  | 229.12d | 0d | (New Resource) | 0.04 | 0 | 0 |  | 0.04 |  |
| 54 |  | Cause and Effect Diagram | resource dependent | 21d | 2021-12-11 | 2022-01-01 | 17 |  |  |  |  | 89d | 0d | (New Resource) | 0.04 | 0 | 0 |  | 0.04 |  |
| 31 |  | Oil Filter Drawing | resource dependent | 20.88d | 2021-12-12 | 2022-01-01 | 30 SS+6d |  |  |  |  | 6.12d | 0d | (New Resource) | 0.05 | 0 | 0 |  | 0.05 |  |
| 49 |  | K/O Drum Drawing | resource dependent | 20.88d | 2021-12-12 A | 2022-01-01 | 41 | 60% | 20.88d |  |  | 6.12d | 0.12d | (New Resource) | 0.05 | 0 | 0 |  | 0.05 | UDF_G4 |
| 24 |  | Spare Parts List for Commissioning & Start-up | resource dependent | 21d | 2021-12-13 | 2022-01-03 | 18 FS-10d |  |  |  |  | 249.12d | 55.25d | (New Resource) | 0.04 | 0 | 0 |  | 0.04 |  |
| 25 |  | Spare Parts List for 2-Year Operation | resource dependent | 21d | 2021-12-13 | 2022-01-03 | 18 FS-10d |  |  |  |  | 249.12d | 55.25d | (New Resource) | 0.04 | 0 | 0 |  | 0.04 |  |
| 26 |  | IOM(including start up, shut down, precommissioning, commissioning procedure) | resource dependent | 21d | 2021-12-13 | 2022-01-03 | 18 FS-10d, 59 FS-10d |  |  |  |  | 246.12d | 0d | (New Resource) | 0.04 | 0 | 0 |  | 0.04 |  |
| 55 |  | Operating Manual (Including Start up, Shut Down, Pre-Commissioning, Commissioning Procedure) | resource dependent | 21d | 2021-12-16 | 2022-01-06 | 26 FS-18d |  |  |  |  | 246.12d | 52.25d | (New Resource) | 0.04 | 0 | 0 |  | 0.04 |  |
| 73 |  | Capital Spare Part | resource dependent | 21d | 2021-12-18 | 2022-01-07 | 57 |  |  |  |  | 244.88d | 51d | (New Resource) | 0.04 | 0 | 0 | UDF_G1 | 0.04 |  |
| 60 |  | Outline Dimensional Drawings (Cabinets Arrangement) | resource dependent | 21d | 2021-12-18 | 2022-01-08 | 18 FS-5d, 34 FS-5d |  |  |  |  | 0.12d |  | (New Resource) | 0.04 | 0 | 0 |  | 0.04 |  |
| 19 |  | Mechanical Calculation of Heat Exchangers and Pressure Vessles | resource dependent | 20.88d | 2021-12-19 | 2022-01-08 | 31 FS-14d, 44 FS-14d, 45 FS-14d, 46 FS-14d, 47 FS-14d, 48 FS-14d, 49 FS-14d, 50 FS-14d, 51 FS-14d, 65 FS-14d, 57 FS-14d, 35 FS-14d, 34 FS-49d, 85 FS-14d |  |  |  |  | 6.12d | 0d | (New Resource) | 0.3 | 0 | 0 |  | 0.3 |  |
| 63 |  | Noise Data Sheet | resource dependent | 20.88d | 2021-12-19 | 2022-01-08 | 32, 57 |  |  |  |  | 244d | 50.12d | (New Resource) | 0.04 | 0 | 0 |  | 0.04 |  |
| 76 |  | Motor Operation & Maintenance Manual | resource dependent | 20.88d | 2021-12-19 | 2022-01-08 | 32 |  |  |  |  | 0d |  | (New Resource) | 0.04 | 0 | 0 |  | 0.04 |  |
| 78 |  | Coupling Drawing | resource dependent | 20.88d | 2021-12-19 | 2022-01-08 | 32 |  |  |  |  | 0d |  | (New Resource) | 0.04 | 0 | 0 |  | 0.04 |  |
| 53 |  | Instrument Data Sheets | resource dependent | 21d | 2021-12-21 | 2022-01-11 | 19 FS-18d, 17 FS-10d |  |  |  |  | 6.12d | 0d | (New Resource) | 0.04 | 0 | 0 |  | 0.04 |  |
| 22 |  | Junction Box Connection Diagrams (Including Wire Schematic to Instruments) | resource dependent | 21d | 2021-12-22 | 2022-01-12 | 21 FS-10d, 18 FS-10d |  |  |  |  | 55d | 0d | (New Resource) | 0.04 | 0 | 0 |  | 0.04 |  |
| 27 |  | I/O List | resource dependent | 21d | 2021-12-22 | 2022-01-12 | 23 FS-10d, 17 |  |  |  |  | 240.12d | 46.25d | (New Resource) | 0.04 | 0 | 0 |  | 0.04 |  |
| 28 |  | Logic Diagram (Print out PLC Program) | resource dependent | 21d | 2021-12-22 | 2022-01-12 | 34 FS-49d, 23 FS-10d |  |  |  |  | 229.12d | 0d | (New Resource) | 0.04 | 0 | 0 |  | 0.04 |  |
| 66 |  | 3D Model | resource dependent | 21d | 2021-12-23 | 2022-01-13 | 18 |  |  |  |  | 28d | 0d | (New Resource) | 0.04 | 0 | 0 |  | 0.04 |  |
| 70 |  | MTO of Insulation | resource dependent | 21d | 2021-12-23 | 2022-01-13 | 18, 10 |  |  |  |  | 49.12d | 1d | (New Resource) | 0.04 | 0 | 0 |  | 0.04 |  |

Notes:
- 222: Expenses: Finish - (cost) 0
- 3: Expenses: LOI Date - (cost) 0
- 4: Expenses: Effective Date - (cost) 0
- 6: Expenses: Bank Garanty Payment Date - (cost) 0
- 7: Expenses: Advanced Payment Date - (cost) 0
- 5: Expenses: K.O.M - (cost) 0

| ID | WBS | Activity | Type | Duration | Start | Finish | Predecessors | Complete | Remaining | Planned start | Planned finish | Total float | Free float | Resources | Cost | % WF | % Plan for Report | % Actual for Report | Gate Status | QA/QC |
| --- | --- | --- | --- | --- | --- | --- | --- | --- | --- | --- | --- | --- | --- | --- | --- | --- | --- | --- | --- | --- |
| 72 |  | Name Plate Drawing | resource dependent | 21d | 2021-12-23 | 2022-01-13 | 18 |  |  |  |  | 258d |  | (New Resource) | 0.04 | 0.04 | 0 | 0 |  |  |
| 58 |  | Equipment List | resource dependent | 21d | 2021-12-24 | 2022-01-13 | 18, 34 FS+8d |  |  |  |  | 238.88d | 45d | (New Resource) | 0.04 | 0.04 | 0 | 0 |  |  |
| 81 |  | Stress Analysis Report | resource dependent | 21d | 2021-12-24 | 2022-01-13 | 61 FS+8d, 18 |  |  |  |  | 238.88d | 45d | (New Resource) | 0.04 | 0.04 | 0 | 0 |  |  |
| 80 |  | Support List | resource dependent | 21d | 2021-12-24 | 2022-01-14 | 79 FS-30d |  |  |  |  | 48.12d | 0d | (New Resource) | 0.04 | 0.04 | 0 | 0 |  |  |
| 68 |  | PMS for Compressor Package | resource dependent | 21d | 2021-12-27 | 2022-01-16 | 29 FS+30d |  |  |  |  | 160.75d | 138.75d | (New Resource) | 0.04 | 0.04 | 0 | 0 | UDF_G1 |  |
| 83 |  | PSV Data Sheet | resource dependent | 21d | 2021-12-28 | 2022-01-18 | 53 FS-14d |  |  |  |  | 177.88d | 0.12d | (New Resource) | 0.04 | 0.04 | 0 | 0 |  |  |
| 56 |  | Operating / Control Philosophy | resource dependent | 21d | 2022-01-02 | 2022-01-23 | 28 FS-10d, 17 |  |  |  |  | 229.12d | 35.25d | (New Resource) | 0.04 | 0.04 | 0 | 0 |  |  |
| 79 |  | Standard Support | resource dependent | 21d | 2022-01-02 | 2022-01-23 | 18 FS+10d |  |  |  |  | 48.12d | 0d | (New Resource) | 0.04 | 0.04 | 0 | 0 |  |  |
| 77 |  | ON/OFF Valve Data Sheet | resource dependent | 21d | 2022-01-11 | 2022-02-01 | 53 |  |  |  |  | 220d | 26.12d | (New Resource) | 0.04 | 0.04 | 0 | 0 |  |  |
| 75 |  | LCS Wiring and Drawing | resource dependent | 21d | 2022-01-12 | 2022-02-02 | 22, 34 FS-39d |  |  |  |  | 108d | 19d | (New Resource) | 0.04 | 0.04 | 0 | 0 |  |  |
| 67 |  | Line List | resource dependent | 21d | 2022-01-13 | 2022-02-03 | 17, 66 |  |  |  |  | 218.12d | 24.25d | (New Resource) | 0.04 | 0.04 | 0 | 0 |  |  |
| 69 |  | Isometrci Drawing for Interconnecting Piping | resource dependent | 21d | 2022-01-13 | 2022-02-03 | 66, 18 |  |  |  |  | 28d | 0d | (New Resource) | 0.04 | 0.04 | 0 | 0 |  |  |
| 74 |  | Special Tools List | resource dependent | 21d | 2022-01-17 | 2022-02-06 | 57 FS+30d |  |  |  |  | 214.88d | 21d | (New Resource) | 0.04 | 0.04 | 0 | 0 |  |  |
| 62 |  | Instrument Hook up Drawings | resource dependent | 21d | 2022-01-22 | 2022-02-12 | 34 FS-9d, 18 FS+30d |  |  |  |  | 0d |  | (New Resource) | 0.04 | 0.04 | 0 | 0 |  |  |
| 33 |  | PLC Wiring Diagrams | resource dependent | 21d | 2022-01-31 | 2022-02-21 | 54 FS+30d |  |  |  |  | 89d | 0d | (New Resource) | 0.04 | 0.04 | 0 | 0 |  |  |
| 16 |  | Vendor Final Book Index | resource dependent | 20.88d | 2022-02-28 | 2022-03-20 | 13, 14, 20, 27, 54, 55, 56, 58, 67, 91, 101, 100, 24, 25, 73, 74, 63, 98, 77, 81 |  |  |  |  | 193.88d |  | (New Resource) | 0.1 | 0.1 | 0 | 0 |  |  |
|  | 3 | **QC DOCUMENT** |  |  | 2021-11-18 | 2022-02-27 |  |  |  |  |  |  |  |  |  |  |  |  |  |  |
| 87 |  | Inspection & Test Plan (ITP) (for Whole Package) | resource dependent | 21d | 2021-11-18 | 2021-12-08 | 11 FS+37d |  |  |  |  | 137.75d | 0d | (New Resource) | 0.1 | 0.1 | 0.0476190476190476 | 0.06 | UDF_G2 | UDF_G4 |
| 92 |  | NDE Procedure | resource dependent | 21d | 2021-11-22 A | 2021-12-29 | 87 FS+20d | 80% | 0d | 2021-11-22 | 2021-12-12 | 218.75d | 81d | (New Resource) | 0.04 | 0.04 | 0.0114285714285714 | 0.032 | UDF_G2 | UDF_G4 |
| 100 |  | Lifting Procedure | resource dependent | 21d | 2021-12-29 | 2022-01-18 | 87 FS+20d |  |  |  |  | 233.88d | 40d | (New Resource) | 0.04 | 0.04 | 0 | 0 |  |  |
| 89 |  | Painting Procedure | resource dependent | 21d | 2021-12-29 | 2022-01-18 | 87 FS+20d |  |  |  |  | 242.75d |  | (New Resource) | 0.04 | 0.04 | 0 | 0 |  |  |
| 90 |  | Packing, Marking and Shipping Procedure | resource dependent | 21d | 2021-12-29 | 2022-01-18 | 87 FS+20d |  |  |  |  | 252.75d |  | (New Resource) | 0.04 | 0.04 | 0 | 0 |  |  |
| 91 |  | Fat Procedure for Control System | resource dependent | 21d | 2021-12-29 | 2022-01-18 | 87 FS+20d |  |  |  |  | 233.88d | 40d | (New Resource) | 0.04 | 0.04 | 0 | 0 |  |  |
| 93 |  | PMI Procedure | resource dependent | 21d | 2021-12-29 | 2022-01-18 | 87 FS+20d |  |  |  |  | 212.88d | 0d | (New Resource) | 0.04 | 0.04 | 0 | 0 |  |  |
| 95 |  | Inspection and Test Plan for Compressor | resource dependent | 21d | 2021-12-29 A | 2021-12-29 | 87 FS+20d | 60% | 0d | 2021-12-29 | 2022-01-18 | 253.75d | 0d | (New Resource) | 0.02 | 0.02 | 0 | 0.012 | UDF_G2 | UDF_G4 |
| 97 |  | Inspection and Test Procedure for Vessle Skids | resource dependent | 21d | 2021-12-29 | 2022-01-18 | 87 FS+20d |  |  |  |  | 197.75d | 60d | (New Resource) | 0.04 | 0.04 | 0 | 0 |  |  |
| 96 |  | Inspection and Test Procedure for Compressor | resource dependent | 21d | 2022-01-05 A | 2021-12-15 | 95 FS-14d | 80% | 0d | 2022-01-05 | 2022-01-25 | 253.75d | 248d | (New Resource) | 0.04 | 0.02 | 0 | 0.016 | UDF_G2 | UDF_G1 |
| 98 |  | Preservation Procedure | resource dependent | 21d | 2022-01-19 | 2022-02-08 | 93, 87, 82 |  |  |  |  | 212.88d | 19d | (New Resource) | 0.04 | 0.04 | 0 | 0 |  |  |
| 99 |  | Hydrostatic Test Procedure | resource dependent | 21d | 2022-01-28 | 2022-02-17 | 87 FS+50d |  |  |  |  | 172.75d | 150.75d | (New Resource) | 0.04 | 0.04 | 0 | 0 |  |  |
| 101 |  | Certificates (Including Welder Qualification Certificate / NDT Personnel Qualification Certificate, etc.) | resource dependent | 21d | 2022-02-07 | 2022-02-27 | 87 FS+60d |  |  |  |  | 193.88d | 0d | (New Resource) | 0.04 | 0.04 | 0 | 0 |  |  |
| 88 |  | Welding Book (WPS, PQR and Welding / NDE Map) | resource dependent | 21d | 2022-02-07 | 2022-02-27 | 87 FS+60d |  |  |  |  | 137.75d | 0d | (New Resource) | 0.04 | 0.04 | 0 | 0 |  |  |
| 94 |  | Inspection Notification | resource dependent | 21d | 2022-02-07 | 2022-02-27 | 87 FS+60d |  |  |  |  | 205.75d |  | (New Resource) |  | 0.02 | 0 | 0 |  |  |

| ID | WBS | Activity | Type | Duration | Start | Finish | Predecessors | Complete | Remaining | Planned start | Planned finish | Total float | Free float | Resources | Cost | % WF | % Plan for Report | % Actual for Report |
| --- | --- | --- | --- | --- | --- | --- | --- | --- | --- | --- | --- | --- | --- | --- | --- | --- | --- | --- |
|  | 3 | **Supply of Material** |  |  | 2021-11-14 | 2022-09-11 |  |  |  |  |  |  |  |  |  |  |  |  |
|  | 1 | **ForeignSupply** |  |  | 2021-11-14 | 2022-09-11 |  |  |  |  |  |  |  |  |  |  |  |  |
|  | 1 | **Special Valves** |  |  | 2022-01-02 | 2022-06-15 |  |  |  |  |  |  |  |  |  |  |  |  |
| 105 |  | PO placement (Other Valves) | resource dependent | 10d | 2022-01-02 | 2022-01-11 | 53 FS-10d, 61 FS-10d |  |  |  |  | 59.62d | 0d | (New Resource) | 0.17 | 0.17 | 0 | 0 |
| 106 |  | EX Work (Other Valves) | resource dependent | 120d | 2022-01-12 | 2022-05-11 | 105 |  |  |  |  | 59.75d | 0d | (New Resource) | 0.68 | 0.68 | 0 | 0 |
| 107 |  | Custom clearance (Other Valves) | resource dependent | 30d | 2022-05-12 | 2022-06-10 | 106 |  |  |  |  | 59.75d | 0d | (New Resource) | 0.51 | 0.51 | 0 | 0 |
| 108 |  | Delivery to shop (Other Valves) | resource dependent | 5d | 2022-06-11 | 2022-06-15 | 107 |  |  |  |  | 59.75d |  | (New Resource) | 0.34 | 0.34 | 0 | 0 |
|  | 2 | **Instrument** |  |  | 2022-01-29 | 2022-05-14 |  |  |  |  |  |  |  |  |  |  |  |  |
| 110 |  | PO placement (Instrument) | resource dependent | 10.12d | 2022-01-29 | 2022-02-08 | 53 FS-14d, 52 FS-14d, 62 FS-14d |  |  |  |  | 0d |  | (New Resource) | 0.17 | 0.17 | 0 | 0 |
| 111 |  | EX Work (Instrument) | resource dependent | 59.88d | 2022-02-08 | 2022-04-09 | 110 |  |  |  |  | 0d |  | (New Resource) | 0.68 | 0.68 | 0 | 0 |
| 112 |  | Custom clearance (Instrument) | resource dependent | 30.12d | 2022-04-09 | 2022-05-09 | 111 |  |  |  |  | 0d |  | (New Resource) | 0.51 | 0.51 | 0 | 0 |
| 113 |  | Delivery to shop (Instrument) | resource dependent | 4.88d | 2022-05-09 | 2022-05-14 | 112 |  |  |  |  | 0d |  | (New Resource) | 0.34 | 0.34 | 0 | 0 |
|  | 3 | **Electrical (Electro motor)** |  |  | 2021-12-29 | 2022-09-11 |  |  |  |  |  |  |  |  |  |  |  |  |
| 115 |  | PO placement (Electrical (Electro motor)) | resource dependent | 9.88d | 2021-12-29 A | 2022-01-08 | 32 FS-10d, 34 FS-49d, 35 FS-10d, 60 FS-10d, 76 FS-10d, 78 FS-10d | 100% | 9.88d |  |  | 0d |  | (New Resource) | 0.5 | 0.5 | 0 | 0 |
| 116 |  | EX Work (Electrical (Electro motor)) | resource dependent | 216d | 2022-01-08 | 2022-08-12 | 115 |  |  |  |  | 0d |  | (New Resource) | 2 | 2 | 0 | 0 |
| 117 |  | Custom clearance (Electrical (Electro motor)) | resource dependent | 25d | 2022-08-12 | 2022-09-06 | 116 |  |  |  |  | 0d |  | (New Resource) | 1.5 | 1.5 | 0 | 0 |
| 118 |  | Delivery to shop (Electrical (Electro motor)) | resource dependent | 5d | 2022-09-06 | 2022-09-11 | 117 |  |  |  |  | 0d |  | (New Resource) | 1 | 1 | 0 | 0 |
|  | 4 | **Filter** |  |  | 2021-12-22 | 2022-04-06 |  |  |  |  |  |  |  |  |  |  |  |  |
| 120 |  | PO placement (Filter) | resource dependent | 9.88d | 2021-12-22 | 2022-01-01 | 65 FS-10d, 31 FS-10d |  |  |  |  | 130.12d | 0d | (New Resource) | 0.17 | 0.17 | 0 | 0 |
| 121 |  | EX Work (Filter) | resource dependent | 60d | 2022-01-01 | 2022-03-02 | 120 |  |  |  |  | 130d | 0d | (New Resource) | 0.68 | 0.68 | 0 | 0 |
| 122 |  | Custom clearance (Filter) | resource dependent | 30d | 2022-03-02 | 2022-04-01 | 121 |  |  |  |  | 130d | 0d | (New Resource) | 0.51 | 0.51 | 0 | 0 |
| 123 |  | Delivery to shop (Filter) | resource dependent | 5d | 2022-04-01 | 2022-04-06 | 122 |  |  |  |  | 130d |  | (New Resource) | 0.34 | 0.34 | 0 | 0 |
|  | 5 | **Oil pump & Oil separator** |  |  | 2021-12-16 | 2022-06-04 |  |  |  |  |  |  |  |  |  |  |  |  |
| 126 |  | EX Work (Oil pump & Oil separator) | resource dependent | 140d | 2021-12-16 | 2022-05-05 | 125 |  |  |  |  | 21.88d | 0d | (New Resource) | 0.68 | 0.68 | 0 | 0 |
| 125 |  | PO placement (Oil pump & Oil separator) | resource dependent | 10d | 2021-12-19 A | 2021-12-28 A | 45 FS-10d, 46 FS-10d, 44 FS-10d, 51 FS-10d | 100% |  | 2021-12-20 | 2021-12-29 |  |  | (New Resource) | 0.17 | 0.17 | 0 | 0.17 |
| 127 |  | Custom clearance (Oil pump & Oil separator) | resource dependent | 25d | 2022-05-05 | 2022-05-30 | 126 |  |  |  |  | 21.88d | 0d | (New Resource) | 0.51 | 0.51 | 0 | 0 |
| 128 |  | Delivery to shop (Oil pump & Oil separator) | resource dependent | 4.88d | 2022-05-30 | 2022-06-04 | 127 |  |  |  |  | 22d | 0d | (New Resource) | 0.34 | 0.34 | 0 | 0 |

| ID | WBS | Activity | Type | Duration | Start | Finish | Predecessors | Complete | Planned start | Planned finish | Total float | Free float | Resources | Cost | % WF | % Plan for Report | % Actual for Report |
| --- | --- | --- | --- | --- | --- | --- | --- | --- | --- | --- | --- | --- | --- | --- | --- | --- | --- |
|  | 6 | **Compressor** |  |  | 2021-11-14 | 2022-07-10 |  |  |  |  |  |  |  |  |  |  |  |
| 130 |  | PO placement (Compressor) | resource dependent | 10d | 2021-11-14 A | 2021-11-24 A | 34 FS-49d, 57 FS-10d | 100% | 2021-11-15 | 2021-11-24 |  |  | (New Resource) | 1.25 | 1.25 | 1.25 | 1.25 |
| 131 |  | EX Work (Compressor) | resource dependent | 180d | 2021-12-08 | 2022-06-05 | 130 |  |  |  | 5.62d | 0d | (New Resource) | 5 | 5 | 0 | 0 |
| 132 |  | Custom clearance (Compressor) | resource dependent | 30d | 2022-06-06 | 2022-07-05 | 131 |  |  |  | 5.75d | 0d | (New Resource) | 3.75 | 3.75 | 0 | 0 |
| 133 |  | Delivery to shop (Compressor) | resource dependent | 5d | 2022-07-06 | 2022-07-10 | 132 |  |  |  | 5.62d | 0d | (New Resource) | 2.5 | 2.5 | 0 | 0 |
|  | 7 | **Other material** |  |  | 2021-12-13 | 2022-05-27 |  |  |  |  |  |  |  |  |  |  |  |
| 135 |  | PO placement (other material) | resource dependent | 10d | 2021-12-13 | 2021-12-23 | 18 FS-10d |  |  |  | 24d | 0d | (New Resource) | 0.07 | 0.07 | 0 | 0 |
| 136 |  | EX Work (Other material) | resource dependent | 120d | 2021-12-23 | 2022-04-22 | 135 |  |  |  | 24d | 0d | (New Resource) | 0.28 | 0.28 | 0 | 0 |
| 137 |  | Custom clearance (Other material) | resource dependent | 30d | 2022-04-22 | 2022-05-22 | 136 |  |  |  | 24d | 0d | (New Resource) | 0.21 | 0.21 | 0 | 0 |
| 138 |  | Delivery to shop (Other material) | resource dependent | 5d | 2022-05-22 | 2022-05-27 | 137 |  |  |  | 24d | 2d | (New Resource) | 0.14 | 0.14 | 0 | 0 |
|  | 2 | **Domestic Supply** |  |  | 2021-12-13 | 2022-03-27 |  |  |  |  |  |  |  |  |  |  |  |
|  | 1 | **Pipe** |  |  | 2022-01-24 | 2022-02-18 |  |  |  |  |  |  |  |  |  |  |  |
| 141 |  | PO placement (Pipe) | resource dependent | 4.88d | 2022-01-24 | 2022-01-29 | 18 FS-10d, 17 FS-10d, 69 FS-10d |  |  |  | 28d | 0d | (New Resource) | 0.1 | 0.1 | 0 | 0 |
| 142 |  | EX Work (Pipe) | resource dependent | 15.12d | 2022-01-29 | 2022-02-13 | 141 |  |  |  | 28d | 0d | (New Resource) | 0.4 | 0.4 | 0 | 0 |
| 143 |  | Delivery to shop (Pipe) | resource dependent | 5d | 2022-02-13 | 2022-02-18 | 142 |  |  |  | 28d | 16d | (New Resource) | 0.5 | 0.5 | 0 | 0 |
|  | 2 | **Plate** |  |  | 2021-12-13 | 2022-01-07 |  |  |  |  |  |  |  |  |  |  |  |
| 145 |  | PO placement (Plate) | resource dependent | 4.88d | 2021-12-13 | 2021-12-18 | 18 FS-10d |  |  |  | 70d | 0d | (New Resource) | 0.1 | 0.1 | 0 | 0 |
| 146 |  | EX Work (Plate) | resource dependent | 15.12d | 2021-12-18 | 2022-01-02 | 145 |  |  |  | 70d | 0d | (New Resource) | 0.4 | 0.4 | 0 | 0 |
| 147 |  | Delivery to shop (Plate) | resource dependent | 5d | 2022-01-02 | 2022-01-07 | 146 |  |  |  | 70d | 0d | (New Resource) | 0.5 | 0.5 | 0 | 0 |
|  | 3 | **Flange & Fitting** |  |  | 2021-12-13 | 2022-02-01 |  |  |  |  |  |  |  |  |  |  |  |
| 149 |  | PO placement (Flange & Fitting) | resource dependent | 4.88d | 2021-12-13 | 2021-12-18 | 18 FS-10d |  |  |  | 45.12d | 0d | (New Resource) | 0.1 | 0.1 | 0 | 0 |
| 150 |  | EX Work (Flange & Fitting) | resource dependent | 40.12d | 2021-12-18 | 2022-01-27 | 149 |  |  |  | 45d | 0d | (New Resource) | 0.4 | 0.4 | 0 | 0 |
| 151 |  | Delivery to shop (Flange & Fitting) | resource dependent | 5d | 2022-01-27 | 2022-02-01 | 150 |  |  |  | 45d | 33d | (New Resource) | 0.5 | 0.5 | 0 | 0 |
|  | 4 | **Gasket** |  |  | 2021-12-13 | 2022-01-22 |  |  |  |  |  |  |  |  |  |  |  |
| 153 |  | PO placement (Gasket) | resource dependent | 4.88d | 2021-12-13 | 2021-12-18 | 18 FS-10d |  |  |  | 55.12d | 0d | (New Resource) | 0.1 | 0.1 | 0 | 0 |
| 154 |  | EX Work (Gasket) | resource dependent | 30.12d | 2021-12-18 | 2022-01-17 | 153 |  |  |  | 55d | 0d | (New Resource) | 0.4 | 0.4 | 0 | 0 |
| 155 |  | Delivery to shop (Gasket) | resource dependent | 4.88d | 2022-01-17 | 2022-01-22 | 154 |  |  |  | 55.12d | 43.12d | (New Resource) | 0.5 | 0.5 | 0 | 0 |

| ID | WBS | Activity | Type | Duration | Start | Finish | Predecessors | Total float | Free float | Resources | Cost | % WF | % Plan for Report | % Actual for Report | Gate Status |
| --- | --- | --- | --- | --- | --- | --- | --- | --- | --- | --- | --- | --- | --- | --- | --- |
|  | 5 | **Bolt & Nut** |  |  | 2021-12-13 | 2022-01-22 |  |  |  |  |  |  |  |  |  |
| 157 |  | PO placement (Bolt & Nut) | resource dependent | 4.88d | 2021-12-13 | 2021-12-18 | 18 FS-10d | 204.12d | 0d | (New Resource) | 0.1 | 0.1 | 0 | 0 |  |
| 158 |  | EX Work (Bolt & Nut) | resource dependent | 30.12d | 2021-12-18 | 2022-01-17 | 157 | 204d | 0d | (New Resource) | 0.4 | 0.4 | 0 | 0 |  |
| 159 |  | Delivery to shop (Bolt & Nut) | resource dependent | 4.88d | 2022-01-17 | 2022-01-22 | 158 | 204.12d |  | (New Resource) | 0.5 | 0.5 | 0 | 0 |  |
|  | 6 | **Electrical** |  |  | 2022-01-12 | 2022-02-21 |  |  |  |  |  |  |  |  |  |
| 161 |  | PO placement (Electrical) | resource dependent | 5d | 2022-01-12 | 2022-01-17 | 18 FS-10d, 22 | 55d | 0d | (New Resource) | 0.1 | 0.1 | 0 | 0 |  |
| 162 |  | EX Work (Electrical) | resource dependent | 30d | 2022-01-17 | 2022-02-16 | 161 | 55d | 0d | (New Resource) | 0.4 | 0.4 | 0 | 0 |  |
| 163 |  | Delivery to shop (Electrical) | resource dependent | 5d | 2022-02-16 | 2022-02-21 | 162 | 55d | 34d | (New Resource) | 0.5 | 0.5 | 0 | 0 |  |
|  | 7 | **Manual valves** |  |  | 2022-01-09 | 2022-02-17 |  |  |  |  |  |  |  |  |  |
| 165 |  | PO placement (Manual valves) | resource dependent | 5d | 2022-01-09 | 2022-01-13 | 18 FS-10d, 61 FS-10d, 83 FS-10d | 177.75d | 0d | (New Resource) | 0.1 | 0.1 | 0 | 0 |  |
| 166 |  | EX Work (Manual valves) | resource dependent | 29.88d | 2022-01-14 | 2022-02-12 | 165 | 177.88d | 0.12d | (New Resource) | 0.4 | 0.4 | 0 | 0 |  |
| 167 |  | Delivery to shop (Manual valves) | resource dependent | 5d | 2022-02-13 | 2022-02-17 | 166 | 177.75d |  | (New Resource) | 0.5 | 0.5 | 0 | 0 |  |
|  | 8 | **Instrument** |  |  | 2022-02-15 | 2022-03-27 |  |  |  |  |  |  |  |  |  |
| 169 |  | PO placement (Domestic Instrument) | resource dependent | 5d | 2022-02-15 | 2022-02-20 | 53 FS+35d, 18 FS+35d | 6d | 0d | (New Resource) | 0.1 | 0.1 | 0 | 0 |  |
| 170 |  | EX Work (Domestic Instrument) | resource dependent | 29.88d | 2022-02-20 | 2022-03-22 | 169 | 6.12d | 0d | (New Resource) | 0.4 | 0.4 | 0 | 0 |  |
| 171 |  | Delivery to shop (Domestic Instrument) | resource dependent | 5d | 2022-03-22 | 2022-03-27 | 170 | 6d | 0d | (New Resource) | 0.5 | 0.5 | 0 | 0 |  |
|  | 9 | **PLC** |  |  | 2022-02-11 | 2022-03-23 |  |  |  |  |  |  |  |  |  |
| 173 |  | PO placement (PLC) | resource dependent | 5d | 2022-02-11 | 2022-02-16 | 33 FS-10d, 18 FS-10d, 75 FS-10d | 89d | 0d | (New Resource) | 0.1 | 0.1 | 0 | 0 | UDF_G4 |
| 174 |  | EX Work (PLC) | resource dependent | 30d | 2022-02-16 | 2022-03-18 | 173 | 89d | 0d | (New Resource) | 0.4 | 0.4 | 0 | 0 |  |
| 175 |  | Delivery to shop (PLC) | resource dependent | 5d | 2022-03-18 | 2022-03-23 | 174 | 89d | 67d | (New Resource) | 0.5 | 0.5 | 0 | 0 |  |
|  | 10 | **Other material** |  |  | 2022-01-04 | 2022-02-13 |  |  |  |  |  |  |  |  |  |
| 177 |  | PO placement (Other material (Domestic) ) | resource dependent | 5d | 2022-01-04 | 2022-01-09 | 18 FS-10d, 70 FS-10d, 80 FS-10d | 48d | 0d | (New Resource) | 0.1 | 0.1 | 0 | 0 |  |
| 178 |  | EX Work (Other material(Domestic)) | resource dependent | 30d | 2022-01-09 | 2022-02-08 | 177 | 48.12d | 0d | (New Resource) | 0.4 | 0.4 | 0 | 0 |  |
| 179 |  | Delivery to shop (Other material(Domestic)) | resource dependent | 5d | 2022-02-08 | 2022-02-13 | 178 | 48d | 42d | (New Resource) | 0.5 | 0.5 | 0 | 0 |  |

| ID | WBS | Activity | Type | Duration | Start | Finish | Predecessors | Total float | Free float | Resources | Cost | % WF | % Plan for Report | % Actual for Report |
| --- | --- | --- | --- | --- | --- | --- | --- | --- | --- | --- | --- | --- | --- | --- |
|  | 4 | **Fabrication** |  |  | 2022-01-07 | 2022-09-28 |  |  |  |  |  |  |  |  |
| 214 |  | Visual & DIM. Inspection | resource dependent | 3d | 2022-09-15 | 2022-09-18 | 213 | 0d |  | (New Resource) | 4 | 4 | 0 | 0 |
| 215 |  | Surface Preparation | resource dependent | 3d | 2022-09-18 | 2022-09-21 | 214, 89 | 0d |  | (New Resource) | 2.5 | 2.5 | 0 | 0 |
| 216 |  | Painting | resource dependent | 5d | 2022-09-21 | 2022-09-26 | 215, 89, 94 | 0d |  | (New Resource) | 2.5 | 2.5 | 0 | 0 |
| 217 |  | Final Check | resource dependent | 2d | 2022-09-26 | 2022-09-28 | 216 | 0d |  | (New Resource) | 3 | 3 | 0 | 0 |
|  | 1 | **Fabrication For Compressor unit** |  |  | 2022-03-12 | 2022-08-24 |  |  |  |  |  |  |  |  |
| 183 |  | Oil filter | resource dependent | 120.12d | 2022-03-12 | 2022-07-10 | 143, 147, 151, 155, 179 FS-15d, 171 FS-15d | 5.75d | 0.12d | (New Resource) | 0.33 | 0.33 | 0 | 0 |
| 184 |  | Oil cooler | resource dependent | 120.12d | 2022-03-12 | 2022-07-10 | 143, 147, 151, 155, 179 FS-15d, 171 FS-15d | 5.75d | 0.12d | (New Resource) | 0.99 | 0.99 | 0 | 0 |
| 185 |  | Filter dryer | resource dependent | 120.12d | 2022-03-12 | 2022-07-10 | 143, 147, 151, 155, 179 FS-15d, 171 FS-15d |  |  | (New Resource) | 0.33 | 0.33 | 0 | 0 |
| 182 |  | Compressor unit Fabrication | resource dependent | 20.12d | 2022-06-04 | 2022-06-24 | 128, 113, 171, 68 | 21.75d | 16.12d | (New Resource) | 1.36 | 1.36 | 0 | 0 |
| 186 |  | Part Assembly | resource dependent | 19.88d | 2022-07-11 | 2022-07-30 | 183, 184, 185, 182, 133 | 5.88d | 0.12d | (New Resource) | 1.35 | 1.35 | 0 | 0 |
| 187 |  | Part Welding | resource dependent | 20d | 2022-07-31 | 2022-08-19 | 186, 88 | 5.75d | 0d | (New Resource) | 0.82 | 0.82 | 0 | 0 |
| 188 |  | Running test | resource dependent | 5d | 2022-08-20 | 2022-08-24 | 187, 96 | 5.75d |  | (New Resource) | 0.82 | 0.82 | 0 | 0 |
|  | 2 | **Fabrication For Condensor** |  |  | 2022-03-06 | 2022-06-22 |  |  |  |  |  |  |  |  |
| 190 |  | Part Fabrication-(cutting,rolling,casting) | resource dependent | 30.12d | 2022-03-06 | 2022-04-05 | 143, 147, 151, 155, 163 FS-21d, 171 FS-21d, 47 | 52.88d | 0d | (New Resource) | 3.31 | 3.31 | 0 | 0 |
| 191 |  | Part Assembly | resource dependent | 50d | 2022-04-05 | 2022-05-25 | 190 | 53d | 0d | (New Resource) | 1.05 | 1.05 | 0 | 0 |
| 192 |  | Part Welding | resource dependent | 24.88d | 2022-05-25 | 2022-06-19 | 191, 88 | 53d | 0d | (New Resource) | 0.82 | 0.82 | 0 | 0 |
| 193 |  | NDT Condensor | resource dependent | 3d | 2022-06-19 | 2022-06-22 | 192, 92 | 53d |  | (New Resource) | 0.82 | 0.82 | 0 | 0 |
|  | 3 | **Fabrication For Hexane chiller** |  |  | 2022-04-17 | 2022-08-30 |  |  |  |  |  |  |  |  |
| 195 |  | Part Fabrication-(cutting,rolling,casting) | resource dependent | 40d | 2022-04-17 | 2022-05-27 | 143, 147, 151, 155, 163, 171 FS-15d, 113 FS-27d | 0d |  | (New Resource) | 3.31 | 3.31 | 0 | 0 |
| 196 |  | Part Assembly | resource dependent | 65d | 2022-05-27 | 2022-07-31 | 195, 71 | 0d |  | (New Resource) | 1.05 | 1.05 | 0 | 0 |
| 197 |  | Part Welding | resource dependent | 25d | 2022-07-31 | 2022-08-25 | 196, 88 | 0d |  | (New Resource) | 0.82 | 0.82 | 0 | 0 |
| 198 |  | NDT Hexane chiller | resource dependent | 5d | 2022-08-25 | 2022-08-30 | 197, 92 | 0d |  | (New Resource) | 0.82 | 0.82 | 0 | 0 |
|  | 4 | **Fabrication For Skid** |  |  | 2022-01-07 | 2022-03-29 |  |  |  |  |  |  |  |  |
| 200 |  | Part Fabrication-(cutting,rolling,casting) | resource dependent | 20d | 2022-01-07 | 2022-01-27 | 147 | 148.88d | 0d | (New Resource) | 3.31 | 3.31 | 0 | 0 |
| 201 |  | Part Assembly | resource dependent | 20d | 2022-01-27 | 2022-02-16 | 200 | 149d | 11.25d | (New Resource) | 1.05 | 1.05 | 0 | 0 |
| 202 |  | Part Welding | resource dependent | 19.88d | 2022-02-28 | 2022-03-19 | 201, 88 | 137.88d | 0.12d | (New Resource) | 0.82 | 0.82 | 0 | 0 |
| 203 |  | NDT Skid | resource dependent | 10d | 2022-03-20 | 2022-03-29 | 202, 92, 97 | 137.75d |  | (New Resource) | 0.82 | 0.82 | 0 | 0 |

| ID | WBS | Activity | Type | Duration | Start | Finish | Predecessors | Total float | Free float | Resources | Cost | % WF | % Plan for Report | % Actual for Report |
| --- | --- | --- | --- | --- | --- | --- | --- | --- | --- | --- | --- | --- | --- | --- |
|  | 5 | **Fabrication For Other** |  |  | 2022-05-29 | 2022-07-23 |  |  |  |  |  |  |  |  |
| 205 |  | Part Fabrication-(cutting,rolling,casting) | resource dependent | 19.88d | 2022-05-29 | 2022-06-18 | 143, 147, 151, 155, 179, 163, 171, 175, 128 FS-6d, 138 | 22.12d | 0d | (New Resource) | 1.75 | 1.75 | 0 | 0 |
| 206 |  | Part Assembly | resource dependent | 15.12d | 2022-06-18 | 2022-07-03 | 205 | 22d | 0d | (New Resource) | 0.75 | 0.75 | 0 | 0 |
| 207 |  | Part Welding | resource dependent | 15d | 2022-07-03 | 2022-07-18 | 206, 88 | 22d | 0d | (New Resource) | 0.25 | 0.25 | 0 | 0 |
| 208 |  | Hydro test | resource dependent | 4.88d | 2022-07-18 | 2022-07-23 | 207, 99 | 22.12d |  | (New Resource) | 0.25 | 0.25 | 0 | 0 |
|  | 6 | **Assembly of packages on skid** |  |  | 2022-08-14 | 2022-09-15 |  |  |  |  |  |  |  |  |
| 210 |  | Inter connecting piping | resource dependent | 15d | 2022-08-14 | 2022-08-29 | 188 FS-16d, 193, 198 FS-16d, 203, 167, 108, 123, 159, 208, 118 FS-28d | 0d |  | (New Resource) | 3.31 | 3.31 | 0 | 0 |
| 211 |  | Part Assembly | resource dependent | 4.88d | 2022-08-29 | 2022-09-03 | 210 | 0d |  | (New Resource) | 1.05 | 1.05 | 0 | 0 |
| 212 |  | Part Welding | resource dependent | 7d | 2022-09-03 | 2022-09-10 | 211, 88 FS-10d | 0d |  | (New Resource) | 0.82 | 0.82 | 0 | 0 |
| 213 |  | NDT packages on skid | resource dependent | 5.12d | 2022-09-10 | 2022-09-15 | 212, 92 | 0d |  | (New Resource) | 0.82 | 0.82 | 0 | 0 |
|  | 5 | **FINAL INSPECTION TEST and RELEASE NOTE for Ex-Work** |  |  | 2022-09-28 | 2022-09-30 |  |  |  |  |  |  |  |  |
| 219 |  | FINAL INSPECTION TEST and RELEASE NOTE for Ex-Work | resource dependent | 2d | 2022-09-28 | 2022-09-30 | 217, 90, 72 | 0d |  | (New Resource) | 10 | 10 | 0 | 0 |
|  | 6 | **Final Data Book** |  |  | 2022-09-30 | 2022-10-04 |  |  |  |  |  |  |  |  |
| 221 |  | VENDOR FINAL DATA BOOK | resource dependent | 4.12d | 2022-09-30 | 2022-10-04 | 219, 16 | 0d |  | (New Resource) | 5 | 5 | 0 | 0 |
